# CARTA-icalma

Schedule from MS Project, 2021-02-01 to 2021-07-13, status date 2021-08-02, 10 hours a day.
fca

## Calendars

- Estándar: Mon-Sun 09:00-13:00, 15:00-19:00.

## Schedule

| ID | WBS | Task | Duration | Start | Finish | Predecessors | Total slack | Free slack | Constraint | Deadline |
| --- | --- | --- | --- | --- | --- | --- | --- | --- | --- | --- |
| 1 | 1 | **OBRAS DE PARALELISMO Y ATRAVIESOS RUTA J-25** | 130d | 2021-02-01 | 2021-07-13 |  | 14.8d |  |  | 2021-07-31 |
| 2 | 1.1 | **Obras Preliminares** | 17d | 2021-02-01 | 2021-02-22 |  | 14.8d |  |  |  |
| 3 | 1.1.1 | Entrega de Terreno | 2d | 2021-02-01 | 2021-02-03 |  | 14.8d | 0d | start no earlier than 2021-02-01 |  |
| 4 | 1.1.2 | Instalacion de faenas | 4d | 2021-02-03 | 2021-02-08 | 3 | 14.8d | 0d | start no earlier than 2021-02-03 |  |
| 5 | 1.1.3 | Entrega de Boletas de Garantia Vialidad | 5d | 2021-02-03 | 2021-02-09 | 3 | 137.8d |  | start no earlier than 2021-02-03 |  |
| 6 | 1.1.4 | Replanteo de Obras Civiles | 7d | 2021-02-08 | 2021-02-17 | 4 | 14.8d | 0d | start no earlier than 2021-02-08 |  |
| 7 | 1.1.5 | Identificación de Vias Afectadas | 5d | 2021-02-03 | 2021-02-09 | 3 | 137.8d |  | start no earlier than 2021-02-03 |  |
| 8 | 1.1.6 | Programa de Operación y Faja Vial | 7d | 2021-02-03 | 2021-02-12 | 3 | 18.8d | 4d | start no earlier than 2021-02-03 |  |
| 9 | 1.1.7 | Señalizacion provisoria | 4d | 2021-02-17 | 2021-02-22 | 6, 8 | 14.8d | 0d | start no earlier than 2021-02-17 |  |
| 10 | 1.2 | **Movimiento de tierra J-25 km 17,94 - 20** | 23d | 2021-02-22 | 2021-03-22 |  | 14.8d |  |  |  |
| 11 | 1.2.1 | Despeje y Limpieza de la Faja | 2d | 2021-02-22 | 2021-02-24 | 9 | 14.8d | 0d | start no earlier than 2020-12-21 |  |
| 12 | 1.2.2 | Excavacion en terreno natural | 5d | 2021-02-24 | 2021-03-02 | 11 | 14.8d | 0d | start no earlier than 2020-12-02 |  |
| 13 | 1.2.3 | Preparacion de fondo de Zanja | 2d | 2021-03-03 | 2021-03-05 | 12 | 14.8d | 0d | start no earlier than 2020-12-09 |  |
| 14 | 1.2.4 | Cama de Areana | 2d | 2021-03-05 | 2021-03-07 | 13 | 14.8d | 0d | start no earlier than 2020-12-11 |  |
| 15 | 1.2.5 | Instalacion de Tuberia | 3d | 2021-03-08 | 2021-03-11 | 14 | 104.8d | 0d | start no earlier than 2020-12-14 |  |
| 16 | 1.2.6 | **Hincado Atraviesos** | 6.5d | 2021-03-05 | 2021-03-13 |  | 112.3d |  |  |  |
| 17 | 1.2.6.1 | Hincado | 3d | 2021-03-05 | 2021-03-09 | 13 | 112.8d | 0d | start no earlier than 2020-04-05 |  |
| 18 | 1.2.6.2 | Instalación Cañeria HDPE Atraviesos | 1.5d | 2021-03-09 | 2021-03-11 | 17 | 112.8d | 0.5d | start no earlier than 2020-08-25 |  |
| 19 | 1.2.6.3 | Conexiones hidraulicas | 1.5d | 2021-03-11 | 2021-03-13 | 18, 15 | 112.3d |  | start no earlier than 2020-12-24 |  |
| 20 | 1.2.7 | **Instalación de Cámaras** | 9d | 2021-03-11 | 2021-03-22 |  | 104.8d |  |  |  |
| 21 | 1.2.7.1 | Enfierraduras | 2d | 2021-03-11 | 2021-03-14 | 15 | 104.8d | 0d | start no earlier than 2021-02-12 |  |
| 22 | 1.2.7.2 | Moldajes | 1d | 2021-03-14 | 2021-03-15 | 21 | 104.8d | 0d | start no earlier than 2021-02-12 |  |
| 23 | 1.2.7.3 | Hormigonado | 3d | 2021-03-15 | 2021-03-19 | 22 | 104.8d | 0d | start no earlier than 2021-02-12 |  |
| 24 | 1.2.7.4 | Instalación de Cámaras | 2d | 2021-03-19 | 2021-03-21 | 23 | 104.8d | 0d | start no earlier than 2021-02-12 |  |
| 25 | 1.2.7.5 | Conexiones hidraulicas | 1d | 2021-03-21 | 2021-03-22 | 24 | 104.8d |  | start no earlier than 2021-02-12 |  |
| 26 | 1.2.8 | Relleno Preliminar | 2d | 2021-03-08 | 2021-03-10 | 14 | 14.8d | 0d | start no earlier than 2020-12-18 |  |
| 27 | 1.2.9 | Compactacion de Relleno | 2d | 2021-03-10 | 2021-03-12 | 26 | 14.8d | 0d | start no earlier than 2020-12-20 |  |
| 28 | 1.2.10 | Ejecucion de Relleno de Zanja | 3d | 2021-03-13 | 2021-03-16 | 27 | 14.8d | 0d | start no earlier than 2020-12-23 |  |
| 29 | 1.2.11 | Compactacion de Relleno de Zanja | 2d | 2021-03-16 | 2021-03-19 | 28 | 107.8d |  | start no earlier than 2020-12-26 |  |
| 30 | 1.2.12 | Retiro de Excedentes | 2d | 2021-03-16 | 2021-03-19 | 28 | 14.8d | 0d | start no earlier than 2021-03-16 |  |

| ID | WBS | Task | Duration | Start | Finish | Predecessors | Total slack | Free slack | Constraint |
| --- | --- | --- | --- | --- | --- | --- | --- | --- | --- |
| 31 | 1.3 | **Movimiento de tierra J-25 km 20-22** | 25d | 2021-03-19 | 2021-04-19 |  | 14.8d |  |  |
| 32 | 1.3.1 | Despeje y Limpieza de la Faja | 2d | 2021-03-19 | 2021-03-21 | 30 | 14.8d | 0d | start no earlier than 2021-01-27 |
| 33 | 1.3.2 | Excavacion en terreno natural | 5d | 2021-03-21 | 2021-03-27 | 32 | 14.8d | 0d | start no earlier than 2021-02-02 |
| 34 | 1.3.3 | Preparacion de fondo de Zanja | 2d | 2021-03-28 | 2021-03-30 | 33 | 14.8d | 0d | start no earlier than 2021-02-05 |
| 35 | 1.3.4 | Cama de Areana | 2d | 2021-03-30 | 2021-04-01 | 34 | 14.8d | 0d | start no earlier than 2021-02-07 |
| 36 | 1.3.5 | Instalacion de Tuberia | 3d | 2021-04-02 | 2021-04-05 | 35 | 77.8d | 0d | start no earlier than 2021-02-11 |
| 37 | 1.3.6 | **Cruce N°1 con tubería adosada a puente** | 11d | 2021-04-05 | 2021-04-19 |  | 82.8d |  |  |
| 38 | 1.3.6.1 | Maestranza Perfil angulo | 4d | 2021-04-05 | 2021-04-10 | 36 | 83.8d | 1d | start no earlier than 2021-03-12 |
| 39 | 1.3.6.2 | Montaje perfiles con anclaje | 3d | 2021-04-12 | 2021-04-15 | 38 | 82.8d | 0d | start no earlier than 2021-04-12 |
| 40 | 1.3.6.3 | Colocación de tuberías de encamisado con abrazaderas | 3d | 2021-04-15 | 2021-04-19 | 39 | 82.8d |  | start no earlier than 2021-03-12 |
| 41 | 1.3.7 | **Hincado Atraviesos** | 6.5d | 2021-03-30 | 2021-04-07 |  | 92.3d |  |  |
| 42 | 1.3.7.1 | Hincado | 3d | 2021-03-30 | 2021-04-03 | 34 | 92.8d | 0d | start no earlier than 2020-03-12 |
| 43 | 1.3.7.2 | Instalación Cañeria HDPE Atraviesos | 1.5d | 2021-04-03 | 2021-04-05 | 42 | 92.8d | 0.5d | start no earlier than 2020-08-01 |
| 44 | 1.3.7.3 | Conexiones hidraulicas | 1.5d | 2021-04-05 | 2021-04-07 | 43, 36 | 92.3d |  | start no earlier than 2021-01-25 |
| 45 | 1.3.8 | **Instalación de Cámaras** | 9d | 2021-04-05 | 2021-04-16 |  | 84.8d |  |  |
| 46 | 1.3.8.1 | Enfierraduras | 2d | 2021-04-05 | 2021-04-08 | 36 | 84.8d | 0d | start no earlier than 2021-03-12 |
| 47 | 1.3.8.2 | Moldajes | 1d | 2021-04-08 | 2021-04-09 | 46 | 84.8d | 0d | start no earlier than 2021-03-12 |
| 48 | 1.3.8.3 | Hormigonado | 3d | 2021-04-09 | 2021-04-13 | 47 | 84.8d | 0d | start no earlier than 2021-03-12 |
| 49 | 1.3.8.4 | Instalación de Cámaras | 2d | 2021-04-13 | 2021-04-15 | 48 | 84.8d | 0d | start no earlier than 2021-03-12 |
| 50 | 1.3.8.5 | Conexiones hidraulicas | 1d | 2021-04-15 | 2021-04-16 | 49 | 84.8d |  | start no earlier than 2021-03-12 |
| 51 | 1.3.9 | Relleno Preliminar | 2d | 2021-04-02 | 2021-04-04 | 35 | 14.8d | 0d | start no earlier than 2021-02-14 |
| 52 | 1.3.10 | Compactacion de Relleno | 2d | 2021-04-04 | 2021-04-06 | 51 | 14.8d | 0d | start no earlier than 2021-02-16 |
| 53 | 1.3.11 | Ejecucion de Relleno de Zanja | 3d | 2021-04-07 | 2021-04-10 | 52 | 14.8d | 0d | start no earlier than 2021-02-20 |
| 54 | 1.3.12 | Compactacion de Relleno de Zanja | 3d | 2021-04-10 | 2021-04-14 | 53 | 86.8d |  | start no earlier than 2021-02-24 |
| 55 | 1.3.13 | Retiro de Excedentes | 2d | 2021-04-10 | 2021-04-13 | 53 | 14.8d | 0d | start no earlier than 2021-03-19 |

| ID | WBS | Task | Duration | Start | Finish | Predecessors | Total slack | Free slack | Constraint |
| --- | --- | --- | --- | --- | --- | --- | --- | --- | --- |
| 56 | 1.4 | **Movimiento de tierra J-25 km 22-24** | 31d | 2021-04-13 | 2021-05-21 |  | 14.8d |  |  |
| 57 | 1.4.1 | Despeje y Limpieza de la Faja | 2d | 2021-04-13 | 2021-04-15 | 55 | 14.8d | 0d | start no earlier than 2021-03-31 |
| 58 | 1.4.2 | Excavacion en terreno natural | 5d | 2021-04-15 | 2021-04-21 | 57 | 14.8d | 0d | start no earlier than 2021-03-30 |
| 59 | 1.4.3 | Preparacion de fondo de Zanja | 2d | 2021-04-22 | 2021-04-24 | 58 | 14.8d | 0d | start no earlier than 2021-04-02 |
| 60 | 1.4.4 | Cama de Areana | 2d | 2021-04-24 | 2021-04-26 | 59 | 14.8d | 0d | start no earlier than 2021-04-12 |
| 61 | 1.4.5 | Instalacion de Tuberia | 3d | 2021-04-27 | 2021-04-30 | 60 | 57.8d | 0d | start no earlier than 2021-04-08 |
| 62 | 1.4.6 | **Cruce N°2 con machones de anclaje** | 17d | 2021-04-30 | 2021-05-21 |  | 56.8d |  |  |
| 63 | 1.4.6.1 | Excavación | 3d | 2021-04-30 | 2021-05-04 | 61 | 57.8d | 0d | start no earlier than 2021-03-12 |
| 64 | 1.4.6.2 | Relleno Estructural | 2d | 2021-05-05 | 2021-05-08 | 63 | 56.8d | 0d | start no earlier than 2021-05-05 |
| 65 | 1.4.6.3 | Retiro de Excedentes | 1d | 2021-05-04 | 2021-05-05 | 63 | 69.8d |  | start no earlier than 2021-03-12 |
| 66 | 1.4.6.4 | Emplantillado | 2d | 2021-05-08 | 2021-05-10 | 64 | 56.8d | 0d |  |
| 67 | 1.4.6.5 | Montaje enfierradura | 5d | 2021-05-10 | 2021-05-16 | 66 | 56.8d | 0d |  |
| 68 | 1.4.6.6 | Moldajes | 3d | 2021-05-17 | 2021-05-20 | 67 | 56.8d | 0d |  |
| 69 | 1.4.6.7 | Hormigonado | 1d | 2021-05-20 | 2021-05-21 | 68 | 56.8d |  | start no earlier than 2021-05-14 |
| 70 | 1.4.7 | **Hincado Atraviesos** | 6.5d | 2021-04-24 | 2021-05-02 |  | 72.3d |  |  |
| 71 | 1.4.7.1 | Hincado | 3d | 2021-04-24 | 2021-04-28 | 59 | 72.8d | 0d | start no earlier than 2020-03-12 |
| 72 | 1.4.7.2 | Instalación Cañeria HDPE Atraviesos | 1.5d | 2021-04-28 | 2021-04-30 | 71 | 72.8d | 0.5d | start no earlier than 2020-08-01 |
| 73 | 1.4.7.3 | Conexiones hidraulicas | 1.5d | 2021-04-30 | 2021-05-02 | 72, 61 | 72.3d |  | start no earlier than 2021-01-25 |
| 74 | 1.4.8 | **Instalación de Cámaras** | 14d | 2021-04-30 | 2021-05-18 |  | 59.8d |  |  |
| 75 | 1.4.8.1 | Enfierraduras | 3d | 2021-04-30 | 2021-05-04 | 61 | 59.8d | 0d | start no earlier than 2021-03-12 |
| 76 | 1.4.8.2 | Moldajes | 2d | 2021-05-04 | 2021-05-06 | 75 | 59.8d | 0d | start no earlier than 2021-03-12 |
| 77 | 1.4.8.3 | Hormigonado | 4d | 2021-05-07 | 2021-05-11 | 76 | 59.8d | 0d | start no earlier than 2021-03-12 |
| 78 | 1.4.8.4 | Instalación de Cámaras | 3d | 2021-05-12 | 2021-05-15 | 77 | 59.8d | 0d | start no earlier than 2021-03-12 |
| 79 | 1.4.8.5 | Conexiones hidraulicas | 2d | 2021-05-15 | 2021-05-18 | 78 | 59.8d |  | start no earlier than 2021-03-12 |
| 80 | 1.4.9 | Relleno Preliminar | 2d | 2021-04-27 | 2021-04-29 | 60 | 14.8d | 0d | start no earlier than 2021-04-11 |
| 81 | 1.4.10 | Compactacion de Relleno | 2d | 2021-04-29 | 2021-05-01 | 80 | 14.8d | 0d | start no earlier than 2021-04-13 |
| 82 | 1.4.11 | Ejecucion de Relleno de Zanja | 3d | 2021-05-02 | 2021-05-05 | 81 | 14.8d | 0d | start no earlier than 2021-04-17 |
| 83 | 1.4.12 | Compactacion de Relleno de Zanja | 3d | 2021-05-05 | 2021-05-09 | 82 | 66.8d |  | start no earlier than 2021-04-21 |
| 84 | 1.4.13 | Retiro de Excedentes | 2d | 2021-05-05 | 2021-05-08 | 82 | 67.8d |  | start no earlier than 2021-04-13 |

| ID | WBS | Task | Duration | Start | Finish | Predecessors | Total slack | Free slack | Constraint |
| --- | --- | --- | --- | --- | --- | --- | --- | --- | --- |
| 85 | 1.5 | **Movimiento de tierra J-25 km 24-26** | 34.5d | 2021-05-05 | 2021-06-17 |  | 14.8d |  |  |
| 86 | 1.5.1 | Despeje y Limpieza de la Faja | 2d | 2021-05-05 | 2021-05-08 | 82 | 14.8d | 0d | start no earlier than 2021-03-31 |
| 87 | 1.5.2 | Excavacion en terreno natural | 5d | 2021-05-08 | 2021-05-14 | 86 | 14.8d | 0d | start no earlier than 2021-03-30 |
| 88 | 1.5.3 | Preparacion de fondo de Zanja | 2d | 2021-05-14 | 2021-05-16 | 87 | 14.8d | 0d | start no earlier than 2021-04-02 |
| 89 | 1.5.4 | Cama de Areana | 2d | 2021-05-17 | 2021-05-19 | 88 | 14.8d | 0d | start no earlier than 2021-05-04 |
| 90 | 1.5.5 | Instalacion de Tuberia | 3d | 2021-05-19 | 2021-05-23 | 89 | 35.3d | 0d | start no earlier than 2021-04-08 |
| 91 | 1.5.6 | **Hincado Atraviesos** | 6d | 2021-05-17 | 2021-05-24 |  | 54.8d |  |  |
| 92 | 1.5.6.1 | Hincado | 2d | 2021-05-17 | 2021-05-19 | 88 | 56.8d | 0d | start no earlier than 2020-03-12 |
| 93 | 1.5.6.2 | Instalación Cañeria HDPE Atraviesos | 1d | 2021-05-19 | 2021-05-20 | 92 | 56.8d | 2d | start no earlier than 2020-08-01 |
| 94 | 1.5.6.3 | Conexiones hidraulicas | 1d | 2021-05-23 | 2021-05-24 | 90, 93 | 54.8d |  | start no earlier than 2021-01-25 |
| 95 | 1.5.7 | **Instalación de Cámaras** | 20.5d | 2021-05-23 | 2021-06-17 |  | 35.3d |  |  |
| 96 | 1.5.7.1 | Enfierraduras | 4.5d | 2021-05-23 | 2021-05-28 | 90 | 35.3d | 0d | start no earlier than 2021-03-12 |
| 97 | 1.5.7.2 | Moldajes | 3d | 2021-05-28 | 2021-06-01 | 96 | 35.3d | 0d | start no earlier than 2021-03-12 |
| 98 | 1.5.7.3 | Hormigonado | 5d | 2021-06-01 | 2021-06-07 | 97 | 35.3d | 0d | start no earlier than 2021-03-12 |
| 99 | 1.5.7.4 | Instalación de Cámaras | 5d | 2021-06-07 | 2021-06-14 | 98 | 35.3d | 0d | start no earlier than 2021-03-12 |
| 100 | 1.5.7.5 | Conexiones hidraulicas | 3d | 2021-06-14 | 2021-06-17 | 99 | 35.3d |  | start no earlier than 2021-03-12 |
| 101 | 1.5.8 | Relleno Preliminar | 2d | 2021-05-19 | 2021-05-21 | 89 | 14.8d | 0d | start no earlier than 2021-03-14 |
| 102 | 1.5.9 | Compactacion de Relleno | 2d | 2021-05-22 | 2021-05-24 | 101 | 14.8d | 0d | start no earlier than 2021-03-16 |
| 103 | 1.5.10 | Ejecucion de Relleno de Zanja | 3d | 2021-05-24 | 2021-05-28 | 102 | 14.8d | 0d | start no earlier than 2021-03-20 |
| 104 | 1.5.11 | Compactacion de Relleno de Zanja | 3d | 2021-05-28 | 2021-05-31 | 103 | 48.8d |  | start no earlier than 2021-03-24 |
| 105 | 1.5.12 | Retiro de Excedentes | 2d | 2021-05-28 | 2021-05-30 | 103 | 14.8d | 0d | start no earlier than 2021-04-13 |
| 106 | 1.6 | **Movimiento de tierra J-25 km 26-29** | 33d | 2021-05-30 | 2021-07-10 |  | 14.8d |  |  |
| 107 | 1.6.1 | Despeje y Limpieza de la Faja | 2.5d | 2021-05-30 | 2021-06-02 | 105 | 14.8d | 0d | start no earlier than 2020-12-30 |
| 108 | 1.6.2 | Excavacion en terreno natural | 7d | 2021-06-02 | 2021-06-11 | 107 | 14.8d | 0d | start no earlier than 2021-01-05 |
| 109 | 1.6.3 | Preparacion de fondo de Zanja | 3d | 2021-06-11 | 2021-06-15 | 108 | 14.8d | 0d | start no earlier than 2021-01-08 |
| 110 | 1.6.4 | Cama de Areana | 3d | 2021-06-15 | 2021-06-19 | 109 | 14.8d | 0d | start no earlier than 2021-01-10 |
| 111 | 1.6.5 | Instalacion de Tuberia | 4d | 2021-06-19 | 2021-06-24 | 110 | 14.8d | 0d | start no earlier than 2021-01-14 |

| ID | WBS | Task | Duration | Start | Finish | Predecessors | Total slack | Free slack | Constraint |
| --- | --- | --- | --- | --- | --- | --- | --- | --- | --- |
| 112 | 1.6.6 | **Hincado Atraviesos** | 14d | 2021-06-15 | 2021-07-02 |  | 23.3d |  |  |
| 113 | 1.6.6.1 | Hincado | 7d | 2021-06-15 | 2021-06-24 | 109 | 23.3d | 0d | start no earlier than 2020-04-09 |
| 114 | 1.6.6.2 | Instalación Cañeria HDPE Atraviesos | 3.5d | 2021-06-24 | 2021-06-28 | 113 | 23.3d | 0d | start no earlier than 2020-08-29 |
| 115 | 1.6.6.3 | Conexiones hidraulicas | 3.5d | 2021-06-28 | 2021-07-02 | 114, 111 | 23.3d |  | start no earlier than 2021-02-22 |
| 116 | 1.6.7 | **Instalación de Cámaras** | 9d | 2021-06-24 | 2021-07-05 |  | 21.3d |  |  |
| 117 | 1.6.7.1 | Enfierraduras | 2d | 2021-06-24 | 2021-06-26 | 111 | 21.3d | 0d | start no earlier than 2021-03-12 |
| 118 | 1.6.7.2 | Moldajes | 1d | 2021-06-26 | 2021-06-27 | 117 | 21.3d | 0d | start no earlier than 2021-03-12 |
| 119 | 1.6.7.3 | Hormigonado | 3d | 2021-06-27 | 2021-07-01 | 118 | 21.3d | 0d | start no earlier than 2021-03-12 |
| 120 | 1.6.7.4 | Instalación de Cámaras | 2d | 2021-07-01 | 2021-07-04 | 119 | 21.3d | 0d | start no earlier than 2021-03-12 |
| 121 | 1.6.7.5 | Conexiones hidraulicas | 1d | 2021-07-04 | 2021-07-05 | 120 | 21.3d |  | start no earlier than 2021-03-12 |
| 122 | 1.6.8 | Relleno Preliminar | 3d | 2021-06-24 | 2021-06-27 | 111 | 14.8d | 0d | start no earlier than 2021-01-17 |
| 123 | 1.6.9 | Compactacion de Relleno | 3d | 2021-06-27 | 2021-07-01 | 122 | 14.8d | 0d | start no earlier than 2021-01-19 |
| 124 | 1.6.10 | Ejecucion de Relleno de Zanja | 4.5d | 2021-07-01 | 2021-07-07 | 123 | 14.8d | 0d | start no earlier than 2021-01-23 |
| 125 | 1.6.11 | Compactacion de Relleno de Zanja | 3d | 2021-07-07 | 2021-07-10 | 124 | 16.8d |  | start no earlier than 2021-01-27 |
| 126 | 1.6.12 | Retiro de Excedentes | 2d | 2021-07-07 | 2021-07-09 | 124 | 14.8d | 0d | start no earlier than 2021-04-13 |
| 127 | 1.7 | **LEVANTAMIENTO DE FAENA** | 3d | 2021-07-09 | 2021-07-13 |  | 14.8d |  |  |
| 128 | 1.7.1 | Levantamiento de Faena | 3d | 2021-07-09 | 2021-07-13 | 126 | 14.8d |  | start no earlier than 2021-03-16 |
